# ARGENTINA LNG LIGHT FEED

Schedule from Primavera P6, 2025-10-06 to 2026-01-12, data date 2025-10-06.

## Calendars

- ARGLNG-LIGHT FEED ITALY: Mon-Fri 08:00-13:00, 14:00-17:00; Sat-Sun off. Exceptions (off unless hours are given): 2025-10-31 08:00-16:00, 2025-12-08, 2025-12-22 to 2025-12-26, 2025-12-29 to 2026-01-02, 2026-01-06.

## Resources

| Resource | Group |
| --- | --- |
| ARGLNG_LIGHT FEED_INGENIERÍA | labor |

## Schedule

| ID | WBS | Activity | Type | Duration | Start | Finish | Predecessors | Total float | Free float | Resources | ARGLNG_LF_SPECIALITY |
| --- | --- | --- | --- | --- | --- | --- | --- | --- | --- | --- | --- |
|  | 1 | **HITOS** |  |  | 2025-10-06 | 2026-01-12 |  |  |  |  |  |
| A1950 |  | LOI (Effective date) | milestone | 0d | 2025-10-06 | 2025-10-06 |  | 0d |  |  | ARGLNG_LF_PMG |
| A1960 |  | KOM | milestone | 0d | 2025-10-07 | 2025-10-07 | A1950 SF+2d | 0d |  |  | ARGLNG_LF_PMG |
| A2190 |  | Completion of process-related deliverables and activities Project Planning | milestone | 0d | 2025-10-20 | 2025-10-20 | A2020 | 48d |  |  | ARGLNG_LF_PLG |
| A2200 |  | Completion of process-related deliverables and activities Quality Assurance & Control | milestone | 0d | 2025-10-20 | 2025-10-20 | A2010 | 48d |  |  | ARGLNG_LF_QAC |
| A2060 |  | Completion of process-related deliverables and activities Architectural | milestone | 0d | 2025-11-28 | 2025-11-28 | A1320 FF, A1330 FF, A1340 FF | 19d |  |  | ARGLNG_LF_ARC |
| A2180 |  | Completion of process-related deliverables and activities Process safety management | milestone | 0d | 2025-11-28 | 2025-11-28 | A1170, A1190, A1210, A1220 | 19d |  |  | ARGLNG_LF_PSM |
| A2210 |  | Completion of process-related deliverables and activities Structural | milestone | 0d | 2025-11-28 | 2025-11-28 | A1350 | 19d |  |  | ARGLNG_LF_STC |
| A2070 |  | Completion of process-related deliverables and activities Civil and Structure | milestone | 0d | 2025-12-19 | 2025-12-19 | A1280 FF, A1360 FF, A1370 FF, A1400 FF, A1800 FF, A1830 FF, A1840 FF, A1850 FF, A1860 FF | 5d |  |  | ARGLNG_LF_CVS |
| A2080 |  | Completion of process-related deliverables and activities Commissioning | milestone | 0d | 2025-12-19 | 2025-12-19 | A1930 FF | 5d |  |  | ARGLNG_LF_CMM |
| A2090 |  | Completion of process-related deliverables and activities Construction | milestone | 0d | 2025-12-19 | 2025-12-19 | A1940 FF | 5d |  |  | ARGLNG_LF_CON |
| A2100 |  | Completion of process-related deliverables and activities Electrical | milestone | 0d | 2025-12-19 | 2025-12-19 | A1080 FF, A1090 FF, A1410 FF, A1420 FF, A1430 FF, A1440 FF, A1450 FF, A1460 FF, A1470 FF, A1480 FF | 5d |  |  | ARGLNG_LF_ELE |
| A2120 |  | Completion of process-related deliverables and activities HSE | milestone | 0d | 2025-12-19 | 2025-12-19 | A1180, A1200, A2000 | 5d |  |  | ARGLNG_LF_HSE |
| A2130 |  | Completion of process-related deliverables and activities I&C | milestone | 0d | 2025-12-19 | 2025-12-19 | A1490, A1500, A1510, A1520, A1530, A1550, A1560, A1570, A1580, A1590, A1600, A1610, A1620 | 5d |  |  | ARGLNG_LF_INS |
| A2140 |  | Completion of process-related deliverables and activities Mechanical | milestone | 0d | 2025-12-19 | 2025-12-19 | A1140, A1150, A1160, A1380, A1390, A1750, A1760 | 5d |  |  | ARGLNG_LF_STA |
| A2150 |  | Completion of process-related deliverables and activities Pipelines and Flow Lines | milestone | 0d | 2025-12-19 | 2025-12-19 | A1240, A1540, A1630, A1640, A1650, A1660, A1670, A1680, A1690, A1700, A1710, A1720, A1730, A1740, A1770, A1780, A1790, A1810, A1820, A1870, A1880, A1890, A1900, A1910, A1920 | 5d |  |  | ARGLNG_LF_CPLF |
| A2160 |  | Completion of process-related deliverables and activities Piping | milestone | 0d | 2025-12-19 | 2025-12-19 | A1230, A1250, A1260, A1270, A1290, A1300, A1310 | 5d |  |  | ARGLNG_LF_PIP |
| A2170 |  | Completion of process-related deliverables and activities Process | milestone | 0d | 2025-12-19 | 2025-12-19 | A1010, A1020, A1030, A1040, A1050, A1060, A1070, A1100, A1110, A1120, A1130 | 5d |  |  | ARGLNG_LF_PRO |
| A1970 |  | EPC Progressive Lump Sum Technical and Commercial Offer | milestone | 0d | 2026-01-12 | 2026-01-12 | A2050, A2060, A2070, A2080, A2090, A2100, A2110, A2120, A2130, A2140, A2150, A2160, A2170, A2180, A2190, A2200, A2210 | 0d |  |  | ARGLNG_LF_PMG |
| A2110 |  | Completion of process-related deliverables and activities General Project Managemenet | milestone | 0d | 2026-01-12 | 2026-01-12 | A1980, A1990, A2030, A2050, A2040 | 0d |  |  | ARGLNG_LF_PMG |
|  | 2 | **GENERAL PROJECT MANAGEMENT** |  |  | 2025-10-09 | 2026-01-12 |  |  |  |  |  |
| A1980 |  | Light FEED Master Deliverables List (MDL) |  | 6d | 2025-10-09 | 2025-10-16 | A1960 FS+1d | 50d |  | ARGLNG_LIGHT FEED_INGENIERÍA [100 h] | ARGLNG_LF_PMG |
| A1990 |  | Light FEED PEP |  | 6d | 2025-10-13 | 2025-10-20 | A1960 FS+3d | 48d |  | ARGLNG_LIGHT FEED_INGENIERÍA [75 h] | ARGLNG_LF_PMG |
| A2000 |  | Light FEED HSSE Management Plan |  | 49d | 2025-10-13 | 2025-12-19 | A1960 FS+3d | 5d | 0d | ARGLNG_LIGHT FEED_INGENIERÍA [169 h] | ARGLNG_LF_HSE |
| A2010 |  | Light FEED Quality Management Plan |  | 6d | 2025-10-13 | 2025-10-20 | A1960 FS+3d | 48d | 0d | ARGLNG_LIGHT FEED_INGENIERÍA [75 h] | ARGLNG_LF_QAC |
| A2020 |  | Light FEED Detail Schedule |  | 6d | 2025-10-13 | 2025-10-20 | A1960 FS+3d | 48d | 0d | ARGLNG_LIGHT FEED_INGENIERÍA [75 h] | ARGLNG_LF_PLG |
| A2040 |  | Site visit |  | 4d | 2025-10-20 | 2025-10-23 | A1960 FS+8d | 0d |  | ARGLNG_LIGHT FEED_INGENIERÍA | ARGLNG_LF_PMG |
| A2030 |  | Light FEED Close-out Report |  | 42d | 2025-10-22 | 2025-12-19 | A1960 FS+10d | 5d |  | ARGLNG_LIGHT FEED_INGENIERÍA [75 h] | ARGLNG_LF_PMG |
| A2050 |  | EPC Progressive Lump Sum Technical and Commercial Offer. |  | 45d | 2025-10-24 | 2026-01-12 | A2040 | 0d |  | ARGLNG_LIGHT FEED_INGENIERÍA [600 h] | ARGLNG_LF_PMG |

| ID | WBS | Activity | Duration | Start | Finish | Predecessors | Total float | Free float | Resources | ARGLNG_LF_SPECIALITY |
| --- | --- | --- | --- | --- | --- | --- | --- | --- | --- | --- |
|  | 3 | **PLANT** |  | 2025-10-06 | 2025-12-19 |  |  |  |  |  |
| A1020 |  | Hydraulic Calculation Report | 30d | 2025-10-06 | 2025-11-14 | A1950 | 5d | 0d | ARGLNG_LIGHT FEED_INGENIERÍA [125 h] | ARGLNG_LF_PRO |
| A1030 |  | Process Flow Diagrams and H&MB | 30d | 2025-10-06 | 2025-11-14 | A1950 | 5d | 0d | ARGLNG_LIGHT FEED_INGENIERÍA [250 h] | ARGLNG_LF_PRO |
| A1230 |  | Plot Plans | 25d | 2025-10-13 | 2025-11-14 | A1030 SS+5d | 5d | 0d | ARGLNG_LIGHT FEED_INGENIERÍA [375 h] | ARGLNG_LF_PIP |
| A1010 |  | Basis of Design | 20d | 2025-10-20 | 2025-11-14 | A1020 FF | 29d | 24d | ARGLNG_LIGHT FEED_INGENIERÍA [125 h] | ARGLNG_LF_PRO |
| A1040 |  | Utility Flow Diagrams | 10d | 2025-11-17 | 2025-11-28 | A1030 | 19d | 14d | ARGLNG_LIGHT FEED_INGENIERÍA [150 h] | ARGLNG_LF_PRO |
| A1050 |  | Fluid list | 5d | 2025-11-17 | 2025-11-21 | A1030 | 5d | 0d | ARGLNG_LIGHT FEED_INGENIERÍA | ARGLNG_LF_PRO |
| A1060 |  | Process Data Sheets (Main Items) | 5d | 2025-11-17 | 2025-11-21 | A1030 | 5d | 0d | ARGLNG_LIGHT FEED_INGENIERÍA | ARGLNG_LF_PRO |
| A1090 |  | Line Sizing | 5d | 2025-11-17 | 2025-11-21 | A1030 | 24d | 19d | ARGLNG_LIGHT FEED_INGENIERÍA | ARGLNG_LF_ELE |
| A1100 |  | Piping & Instruments Diagrams | 10d | 2025-11-17 | 2025-11-28 | A1030 | 5d | 0d | ARGLNG_LIGHT FEED_INGENIERÍA [300 h] | ARGLNG_LF_PRO |
| A1170 |  | Hazardous Area Classification Layouts | 10d | 2025-11-17 | 2025-11-28 | A1230 | 19d | 0d | ARGLNG_LIGHT FEED_INGENIERÍA [300 h] | ARGLNG_LF_PSM |
| A1180 |  | Firefighting caclulations | 10d | 2025-11-17 | 2025-11-28 | A1230 | 14d | 0d | ARGLNG_LIGHT FEED_INGENIERÍA | ARGLNG_LF_HSE |
| A1190 |  | Fire Fighting Layouts (network and equipment) | 10d | 2025-11-17 | 2025-11-28 | A1180 SS | 14d | 0d | ARGLNG_LIGHT FEED_INGENIERÍA [200 h] | ARGLNG_LF_PSM |
| A1210 |  | HAZID | 10d | 2025-11-17 | 2025-11-28 | A1190 SS | 19d | 0d | ARGLNG_LIGHT FEED_INGENIERÍA [100 h] | ARGLNG_LF_PSM |
| A1220 |  | EAC+ACR | 10d | 2025-11-17 | 2025-11-28 | A1210 SS | 19d | 0d | ARGLNG_LIGHT FEED_INGENIERÍA [100 h] | ARGLNG_LF_PSM |
| A1240 |  | Material Selection Report | 10d | 2025-11-17 | 2025-11-28 | A1050 SS | 5d | 0d | ARGLNG_LIGHT FEED_INGENIERÍA [100 h] | ARGLNG_LF_CPLF |
| A1250 |  | Piping Classes | 10d | 2025-11-17 | 2025-11-28 | A1240 SS | 5d | 0d | ARGLNG_LIGHT FEED_INGENIERÍA [100 h] | ARGLNG_LF_PIP |
| A1260 |  | Simplified Data Sheet for manual valves | 10d | 2025-11-17 | 2025-11-28 | A1250 SS | 5d | 0d | ARGLNG_LIGHT FEED_INGENIERÍA [100 h] | ARGLNG_LF_PIP |
| A1320 |  | Building / Shelter Lists | 10d | 2025-11-17 | 2025-11-28 | A1230 | 5d | 0d | ARGLNG_LIGHT FEED_INGENIERÍA [200 h] | ARGLNG_LF_ARC |
| A1330 |  | Buildings - General Layouts | 10d | 2025-11-17 | 2025-11-28 | A1230 | 19d | 0d | ARGLNG_LIGHT FEED_INGENIERÍA [150 h] | ARGLNG_LF_ARC |
| A1340 |  | Buildings - Architectural typical drawings | 10d | 2025-11-17 | 2025-11-28 | A1230 | 19d | 0d | ARGLNG_LIGHT FEED_INGENIERÍA [150 h] | ARGLNG_LF_ARC |
| A1350 |  | Steel Structures - Preliminary sizing | 10d | 2025-11-17 | 2025-11-28 | A1230 | 19d | 0d | ARGLNG_LIGHT FEED_INGENIERÍA [150 h] | ARGLNG_LF_STC |
| A1360 |  | Foundations - Preliminary sizing | 10d | 2025-11-17 | 2025-11-28 | A1230 | 19d | 14d | ARGLNG_LIGHT FEED_INGENIERÍA [150 h] | ARGLNG_LF_CVS |
| A1370 |  | Foundations - Preliminary General Layout | 10d | 2025-11-17 | 2025-11-28 | A1230 | 19d | 14d | ARGLNG_LIGHT FEED_INGENIERÍA [150 h] | ARGLNG_LF_CVS |
| A1510 |  | Control System Architectures | 10d | 2025-11-17 | 2025-11-28 | A1020 | 5d | 0d | ARGLNG_LIGHT FEED_INGENIERÍA [300 h] | ARGLNG_LF_INS |
| A1520 |  | Control System Technical Specification | 10d | 2025-11-17 | 2025-11-28 | A1510 FF | 5d | 0d | ARGLNG_LIGHT FEED_INGENIERÍA [200 h] | ARGLNG_LF_INS |
| A1070 |  | Equipment Summaries | 5d | 2025-11-24 | 2025-11-28 | A1060 | 19d | 14d | ARGLNG_LIGHT FEED_INGENIERÍA [600 h] | ARGLNG_LF_PRO |
| A1080 |  | Process Electrical Load Lists | 5d | 2025-11-24 | 2025-11-28 | A1060 | 5d | 0d | ARGLNG_LIGHT FEED_INGENIERÍA | ARGLNG_LF_ELE |
| A1110 |  | Process Equipment Calculation Notes | 5d | 2025-11-24 | 2025-11-28 | A1100 SS+5d | 5d | 0d | ARGLNG_LIGHT FEED_INGENIERÍA [150 h] | ARGLNG_LF_PRO |
| A1120 |  | Pressure relieving system calculation reports | 5d | 2025-11-24 | 2025-11-28 | A1110 SS | 5d | 0d | ARGLNG_LIGHT FEED_INGENIERÍA [150 h] | ARGLNG_LF_PRO |
| A1140 |  | Main equipment and packages Supply Specifications | 8d | 2025-11-24 | 2025-12-03 | A1060 | 5d | 0d | ARGLNG_LIGHT FEED_INGENIERÍA | ARGLNG_LF_STA |
| A1380 |  | Supply Specification for LER/LIR | 10d | 2025-11-24 | 2025-12-05 | A1320 SS+5d | 5d | 0d | ARGLNG_LIGHT FEED_INGENIERÍA | ARGLNG_LF_STA |
| A1410 |  | Electrical studies (power source and availability) | 5d | 2025-11-24 | 2025-11-28 | A1080 SS | 19d | 14d | ARGLNG_LIGHT FEED_INGENIERÍA [75 h] | ARGLNG_LF_ELE |
| A1420 |  | Electrical Balances | 5d | 2025-11-24 | 2025-11-28 | A1080 SS | 19d | 14d | ARGLNG_LIGHT FEED_INGENIERÍA [300 h] | ARGLNG_LF_ELE |
| A1430 |  | Electrical One Line Diagrams | 5d | 2025-11-24 | 2025-11-28 | A1080 SS | 5d | 0d | ARGLNG_LIGHT FEED_INGENIERÍA [300 h] | ARGLNG_LF_ELE |
| A1530 |  | Metering Skid Technical Specification | 5d | 2025-11-24 | 2025-11-28 | A1520 SS+5d | 5d | 0d | ARGLNG_LIGHT FEED_INGENIERÍA | ARGLNG_LF_INS |
| A1540 |  | Specification for pipeline valves | 5d | 2025-11-24 | 2025-11-28 | A1260 FF | 5d | 0d | ARGLNG_LIGHT FEED_INGENIERÍA [100 h] | ARGLNG_LF_CPLF |
| A1550 |  | Control System Supply Specification | 5d | 2025-11-24 | 2025-11-28 | A1510 SS+5d | 5d | 0d | ARGLNG_LIGHT FEED_INGENIERÍA | ARGLNG_LF_INS |
| A1610 |  | BVS isolation valve Supply Specification | 5d | 2025-11-25 | 2025-12-01 | A1540 SS+1d | 5d | 0d | ARGLNG_LIGHT FEED_INGENIERÍA | ARGLNG_LF_INS |
| A1130 |  | Operation and Control Philosophies | 14d | 2025-12-01 | 2025-12-19 | A1120 | 5d | 0d | ARGLNG_LIGHT FEED_INGENIERÍA [150 h] | ARGLNG_LF_PRO |
| A1200 |  | Firefighting devices BOQ | 5d | 2025-12-01 | 2025-12-05 | A1190 | 14d | 9d | ARGLNG_LIGHT FEED_INGENIERÍA | ARGLNG_LF_HSE |
| A1270 |  | Main Piping routing (3D Modelling) | 10d | 2025-12-01 | 2025-12-15 | A1100, A1230 | 5d | 0d | ARGLNG_LIGHT FEED_INGENIERÍA | ARGLNG_LF_PIP |
| A1300 |  | Manual valves and special items Supply Specifications | 5d | 2025-12-01 | 2025-12-05 | A1100, A1260 | 5d | 0d | ARGLNG_LIGHT FEED_INGENIERÍA | ARGLNG_LF_PIP |
| A1440 |  | Main Electrical Cables Routing | 5d | 2025-12-01 | 2025-12-05 | A1430, A1230 | 5d | 0d | ARGLNG_LIGHT FEED_INGENIERÍA | ARGLNG_LF_ELE |
| A1470 |  | Electrical equipment Supply Specification | 5d | 2025-12-01 | 2025-12-05 | A1430 | 5d | 0d | ARGLNG_LIGHT FEED_INGENIERÍA | ARGLNG_LF_ELE |
| A1490 |  | Main Instrumentation Cables Routing | 5d | 2025-12-01 | 2025-12-05 | A1440 SS | 5d | 0d | ARGLNG_LIGHT FEED_INGENIERÍA | ARGLNG_LF_INS |
| A1570 |  | Telecom System Supply Specification | 5d | 2025-12-01 | 2025-12-05 | A1550 | 5d | 0d | ARGLNG_LIGHT FEED_INGENIERÍA | ARGLNG_LF_INS |
| A1590 |  | Fiscal Metering Skid Supply Specification | 5d | 2025-12-01 | 2025-12-05 | A1530 | 5d | 0d | ARGLNG_LIGHT FEED_INGENIERÍA | ARGLNG_LF_INS |
| A1280 |  | One line structures for civil inputs | 5d | 2025-12-04 | 2025-12-11 | A1270 SS+3d | 5d | 0d | ARGLNG_LIGHT FEED_INGENIERÍA | ARGLNG_LF_CVS |
| A1450 |  | Cable sizing Calculation | 5d | 2025-12-04 | 2025-12-11 | A1440 SS+3d | 5d | 0d | ARGLNG_LIGHT FEED_INGENIERÍA | ARGLNG_LF_ELE |
| A1150 |  | Main equipment and packages Technical Bid Evaluations | 4d | 2025-12-05 | 2025-12-11 | A1140 FS+1d | 5d | 0d | ARGLNG_LIGHT FEED_INGENIERÍA | ARGLNG_LF_STA |
| A1290 |  | Piping MTO / BOQ | 9d | 2025-12-09 | 2025-12-19 | A1270 SS+5d | 5d | 0d | ARGLNG_LIGHT FEED_INGENIERÍA | ARGLNG_LF_PIP |
| A1400 |  | Concrete works & Steel Structures BOQ | 9d | 2025-12-09 | 2025-12-19 | A1280 SS+2d | 5d | 0d | ARGLNG_LIGHT FEED_INGENIERÍA | ARGLNG_LF_CVS |
| A1460 |  | Electrical BOQ | 9d | 2025-12-09 | 2025-12-19 | A1450 SS+2d | 5d | 0d | ARGLNG_LIGHT FEED_INGENIERÍA | ARGLNG_LF_ELE |
| A1500 |  | Instrumentation BOQ | 9d | 2025-12-09 | 2025-12-19 | A1100, A1490 | 5d | 0d | ARGLNG_LIGHT FEED_INGENIERÍA | ARGLNG_LF_INS |
| A1560 |  | Control System Technical Bid Evaluation | 4d | 2025-12-09 | 2025-12-12 | A1550 FS+5d | 10d | 5d | ARGLNG_LIGHT FEED_INGENIERÍA | ARGLNG_LF_INS |
| A1620 |  | BVS isolation valve Technical Bid Evaluation | 8d | 2025-12-10 | 2025-12-19 | A1610 FS+5d | 5d | 0d | ARGLNG_LIGHT FEED_INGENIERÍA | ARGLNG_LF_INS |
| A1160 |  | Equipment and packages BOQ | 5d | 2025-12-15 | 2025-12-19 | A1150 SS+5d | 5d | 0d | ARGLNG_LIGHT FEED_INGENIERÍA | ARGLNG_LF_STA |
| A1310 |  | Manual valves and special items Technical Bid Evaluations | 4d | 2025-12-16 | 2025-12-19 | A1300 FS+5d | 5d | 0d | ARGLNG_LIGHT FEED_INGENIERÍA | ARGLNG_LF_PIP |
| A1390 |  | Technical Bid Evaluation for LER/LIR | 4d | 2025-12-16 | 2025-12-19 | A1380 FS+5d | 5d | 0d | ARGLNG_LIGHT FEED_INGENIERÍA | ARGLNG_LF_STA |
| A1480 |  | Electrical equipment Technical Bid Evaluation | 4d | 2025-12-16 | 2025-12-19 | A1470 FS+5d | 5d | 0d | ARGLNG_LIGHT FEED_INGENIERÍA | ARGLNG_LF_ELE |
| A1580 |  | Telecom System Technical Bid Evaluation | 4d | 2025-12-16 | 2025-12-19 | A1570 FS+5d | 5d | 0d | ARGLNG_LIGHT FEED_INGENIERÍA | ARGLNG_LF_INS |
| A1600 |  | Fiscal Metering Skid Technical Bid Evaluation | 4d | 2025-12-16 | 2025-12-19 | A1590 FS+5d | 5d | 0d | ARGLNG_LIGHT FEED_INGENIERÍA | ARGLNG_LF_INS |

| ID | WBS | Activity | Duration | Start | Finish | Predecessors | Total float | Free float | Resources | ARGLNG_LF_SPECIALITY |
| --- | --- | --- | --- | --- | --- | --- | --- | --- | --- | --- |
|  | 4 | **PIPELINE** |  | 2025-10-13 | 2025-12-19 |  |  |  |  |  |
| A1810 |  | Overall Pipelines Route Plan | 25d | 2025-10-13 | 2025-11-14 | A1020 SS+5d | 29d | 0d | ARGLNG_LIGHT FEED_INGENIERÍA [60 h] | ARGLNG_LF_CPLF |
| A1840 |  | Topographic Survey - Scope of Work and Technical Requirements for LIGHT FEED | 25d | 2025-10-13 | 2025-11-14 | A1810 SS | 29d | 24d | ARGLNG_LIGHT FEED_INGENIERÍA [40 h] | ARGLNG_LF_CVS |
| A1830 |  | Geotechnical Investigation - Data interpretation Report (desktop study) | 15d | 2025-10-27 | 2025-11-14 | A1810 SS+10d | 29d | 24d | ARGLNG_LIGHT FEED_INGENIERÍA [80 h] | ARGLNG_LF_CVS |
| A1820 |  | Pipeline Crossings List | 10d | 2025-11-03 | 2025-11-14 | A1810 FF | 29d | 24d | ARGLNG_LIGHT FEED_INGENIERÍA [60 h] | ARGLNG_LF_CPLF |
| A1630 |  | Overall Pipeline schematic diagram | 5d | 2025-11-10 | 2025-11-14 | A1020 SS+25d | 29d | 24d | ARGLNG_LIGHT FEED_INGENIERÍA [48 h] | ARGLNG_LF_CPLF |
| A1640 |  | Design Criteria for pipelines | 5d | 2025-11-10 | 2025-11-14 | A1020 SS+25d | 5d | 0d | ARGLNG_LIGHT FEED_INGENIERÍA [80 h] | ARGLNG_LF_CPLF |
| A1650 |  | Pipeline Cathodic Protection Basis of Design | 5d | 2025-11-10 | 2025-11-14 | A1020 SS+25d | 29d | 24d | ARGLNG_LIGHT FEED_INGENIERÍA [80 h] | ARGLNG_LF_CPLF |
| A1660 |  | Pipelines Thickness Calculation and Selection Report | 5d | 2025-11-10 | 2025-11-14 | A1640 SS | 29d | 24d | ARGLNG_LIGHT FEED_INGENIERÍA [60 h] | ARGLNG_LF_CPLF |
| A1670 |  | Buoyancy Calculation Report | 5d | 2025-11-10 | 2025-11-14 | A1640 SS | 29d | 24d | ARGLNG_LIGHT FEED_INGENIERÍA [60 h] | ARGLNG_LF_CPLF |
| A1680 |  | Pipeline Typical Drawings | 5d | 2025-11-10 | 2025-11-14 | A1640 SS | 29d | 24d | ARGLNG_LIGHT FEED_INGENIERÍA [72 h] | ARGLNG_LF_CPLF |
| A1690 |  | Line Pipe Technical Specification & MRQ | 5d | 2025-11-10 | 2025-11-14 | A1640 SS | 14d | 0d | ARGLNG_LIGHT FEED_INGENIERÍA [72 h] | ARGLNG_LF_CPLF |
| A1710 |  | Specification for hot induction bends & MRQ | 5d | 2025-11-10 | 2025-11-14 | A1640 SS | 14d | 0d | ARGLNG_LIGHT FEED_INGENIERÍA [40 h] | ARGLNG_LF_CPLF |
| A1730 |  | Specification for Pipeline Flanges & Fittings (Barred TEEs) & MRQ | 5d | 2025-11-10 | 2025-11-14 | A1640 SS | 14d | 0d | ARGLNG_LIGHT FEED_INGENIERÍA [40 h] | ARGLNG_LF_CPLF |
| A1750 |  | Specification for Scraper Trap & MRQ | 5d | 2025-11-10 | 2025-11-14 | A1640 SS | 14d | 0d | ARGLNG_LIGHT FEED_INGENIERÍA [60 h] | ARGLNG_LF_STA |
| A1770 |  | Specification for Pipeline Monolothic Isolation Joint | 5d | 2025-11-10 | 2025-11-14 | A1640 SS | 14d | 0d | ARGLNG_LIGHT FEED_INGENIERÍA [32 h] | ARGLNG_LF_CPLF |
| A1790 |  | Pipeline Field Joint Coating Specification | 5d | 2025-11-10 | 2025-11-14 | A1640 SS | 29d | 24d | ARGLNG_LIGHT FEED_INGENIERÍA [100 h] | ARGLNG_LF_CPLF |
| A1850 |  | Access roads and circulation plan (based on .kmz) | 20d | 2025-11-10 | 2025-12-05 | A1880 FF, A1890 FF, A1900 FF, A1910 FF | 14d | 9d | ARGLNG_LIGHT FEED_INGENIERÍA [60 h] | ARGLNG_LF_CVS |
| A1860 |  | Earthworks - Preliminary Soil Movement Plan | 20d | 2025-11-10 | 2025-12-05 | A1880 FF, A1890 FF, A1900 FF, A1910 FF | 14d | 9d | ARGLNG_LIGHT FEED_INGENIERÍA [60 h] | ARGLNG_LF_CVS |
| A1870 |  | Material Take Off Pipeline | 20d | 2025-11-10 | 2025-12-05 | A1880 FF, A1890 FF, A1900 FF, A1910 FF | 14d | 9d | ARGLNG_LIGHT FEED_INGENIERÍA [8 h] | ARGLNG_LF_CPLF |
| A1890 |  | Alignment Sheet - Condensate Pipeline to Cental Hub | 20d | 2025-11-10 | 2025-12-05 | A1640 SS | 5d | 0d | ARGLNG_LIGHT FEED_INGENIERÍA [208 h] | ARGLNG_LF_CPLF |
| A1880 |  | Alignment Sheet - Gas Pipeline to Sierra Grande | 10d | 2025-11-17 | 2025-11-28 | A1640 | 5d | 0d | ARGLNG_LIGHT FEED_INGENIERÍA [424 h] | ARGLNG_LF_CPLF |
| A1900 |  | Alignment Sheet - C2 Pipeline | 15d | 2025-11-17 | 2025-12-05 | A1890 FF | 5d | 0d | ARGLNG_LIGHT FEED_INGENIERÍA [120 h] | ARGLNG_LF_CPLF |
| A1910 |  | Alignment Sheet - C3+ Pipeline | 10d | 2025-11-24 | 2025-12-05 | A1890 FF | 14d | 0d | ARGLNG_LIGHT FEED_INGENIERÍA [40 h] | ARGLNG_LF_CPLF |
| A1700 |  | Line Pipe Technical Bid Evaluation | 5d | 2025-12-01 | 2025-12-05 | A1690 FS+10d | 14d | 9d | ARGLNG_LIGHT FEED_INGENIERÍA | ARGLNG_LF_CPLF |
| A1720 |  | Hot Induction Bend Technical Bid Evaluation | 5d | 2025-12-01 | 2025-12-05 | A1710 FS+10d | 14d | 9d | ARGLNG_LIGHT FEED_INGENIERÍA | ARGLNG_LF_CPLF |
| A1740 |  | Pipeline Flanges & Fittings (Barred TEEs) Technical Bid Evaluation | 5d | 2025-12-01 | 2025-12-05 | A1730 FS+10d | 14d | 9d | ARGLNG_LIGHT FEED_INGENIERÍA | ARGLNG_LF_CPLF |
| A1760 |  | Scraper Trap Technical Bid Evaluation | 5d | 2025-12-01 | 2025-12-05 | A1750 FS+10d | 14d | 9d | ARGLNG_LIGHT FEED_INGENIERÍA | ARGLNG_LF_STA |
| A1780 |  | Pipeline Monolothic Isolation Joint Technical Bid Evaluation | 5d | 2025-12-01 | 2025-12-05 | A1770 FS+10d | 14d | 9d | ARGLNG_LIGHT FEED_INGENIERÍA | ARGLNG_LF_CPLF |
| A1920 |  | Detail Crossing Design | 14d | 2025-12-01 | 2025-12-19 | A1880 | 5d | 0d | ARGLNG_LIGHT FEED_INGENIERÍA [300 h] | ARGLNG_LF_CPLF |
| A1800 |  | Geotechnical Investigation - Scope of Work and Plan for Geotechnical Campaign | 9d | 2025-12-09 | 2025-12-19 | A1920 FF | 5d | 0d | ARGLNG_LIGHT FEED_INGENIERÍA [40 h] | ARGLNG_LF_CVS |
| A1930 |  | Pipeline pre-Commissioning and Commissioning Philosophy | 9d | 2025-12-09 | 2025-12-19 | A1900 | 5d | 0d | ARGLNG_LIGHT FEED_INGENIERÍA [60 h] | ARGLNG_LF_CMM |
| A1940 |  | Strategy for hydraulic test, dimensional control and drying | 9d | 2025-12-09 | 2025-12-19 | A1900 | 5d | 0d | ARGLNG_LIGHT FEED_INGENIERÍA [60 h] | ARGLNG_LF_CON |

## Activity codes

| Code | Value | Meaning |
| --- | --- | --- |
| ARGLNG_LF_SPECIALITY | ARGLNG_LF_ARC | ARCHITECTURAL |
| ARGLNG_LF_SPECIALITY | ARGLNG_LF_CMM | COMMISSIONING |
| ARGLNG_LF_SPECIALITY | ARGLNG_LF_CON | CONSTRUCTION |
| ARGLNG_LF_SPECIALITY | ARGLNG_LF_CPLF | PIPELINES AND FLOW LINES |
| ARGLNG_LF_SPECIALITY | ARGLNG_LF_CVS | CIVIL AND STRUCTURE |
| ARGLNG_LF_SPECIALITY | ARGLNG_LF_ELE | ELECTRICAL |
| ARGLNG_LF_SPECIALITY | ARGLNG_LF_HSE | HSE |
| ARGLNG_LF_SPECIALITY | ARGLNG_LF_INS | I&C |
| ARGLNG_LF_SPECIALITY | ARGLNG_LF_PIP | PIPING |
| ARGLNG_LF_SPECIALITY | ARGLNG_LF_PLG | PROJECT PLANNING |
| ARGLNG_LF_SPECIALITY | ARGLNG_LF_PMG | GENERAL PROJECT MANAGEMENT |
| ARGLNG_LF_SPECIALITY | ARGLNG_LF_PRO | PROCESS |
| ARGLNG_LF_SPECIALITY | ARGLNG_LF_PSM | PROCESS SAFETY MANAGEMENT |
| ARGLNG_LF_SPECIALITY | ARGLNG_LF_QAC | QUALITY ASSURANCE & CONTROL |
| ARGLNG_LF_SPECIALITY | ARGLNG_LF_STA | MECHANICAL |
| ARGLNG_LF_SPECIALITY | ARGLNG_LF_STC | STRUCTURAL |
